# 2-2

Schedule from MS Project, 2023-09-15 to 2024-04-04, 2 hours a day, costs in €.
Universite Clermont Auvergne

## Calendars

- SAE: Mon-Fri 08:00-10:00; Sat-Sun off.

## Resources

| Resource | Rate |
| --- | --- |
| A_PE | 20 |
| K_MO | 20 |
| P_LE | 20 |
| D_DA | 20 |
| A_PI | 20 |

## Schedule

| ID | WBS | Task | Duration | Start | Finish | Predecessors | Total slack | Free slack | Resources | Work | Cost |
| --- | --- | --- | --- | --- | --- | --- | --- | --- | --- | --- | --- |
| 1 | 1 | **Étude de courbes de fréquence cardiaque** | 144.83d | 2023-09-15 | 2024-04-04 |  | 0d |  |  | 557.99h | 11,159.78 |
| 2 | 1.1 | **1 - Management de projet** | 144.83d | 2023-09-15 | 2024-04-04 |  | 0d |  |  | 166h | 3,320 |
| 3 | 1.1.1 | **1.1 - Recueil de besoins** | 21.75d | 2023-09-15 | 2023-10-16 |  | 0d |  |  | 75h | 1,500 |
| 4 | 1.1.1.1 | 1.1.1 - Présentation general du projet | 2h | 2023-09-20 | 2023-09-21 | 11 | 0d |  | A_PE | 2h | 40 |
| 5 | 1.1.1.2 | 1.1.2 - Compte rendu 1 | 3h | 2023-09-21 | 2023-09-25 | 4, 10 | 0d |  | A_PE; A_PI; D_DA; K_MO; P_LE | 7h | 140 |
| 6 | 1.1.1.3 | 1.1.3 - Compte rendu 2 | 14h | 2023-09-28 | 2023-10-13 | 7 | 124.08d |  | A_PE; A_PI; D_DA; K_MO; P_LE | 25h | 500 |
| 7 | 1.1.1.4 | 1.1.4 - Backlog (users stories) | 5h | 2023-09-25 | 2023-09-28 | 5 | 124.08d | 0d | D_DA; P_LE | 10h | 200 |
| 8 | 1.1.1.5 | 1.1.7 - Rapport BDD | 6h | 2023-10-09 | 2023-10-16 | 34 | 123.08d |  | A_PE; P_LE; D_DA; K_MO; A_PI | 10h | 200 |
| 9 | 1.1.1.6 | **1.1.5 - Rendez vous** | 4.75d | 2023-09-15 | 2023-09-21 |  | 0d |  |  | 21h | 420 |
| 10 | 1.1.1.6.1 | 1.1.5.1 - Avec le tuteur | 6.5h | 2023-09-15 | 2023-09-21 |  | 0d |  | A_PE; A_PI; D_DA; K_MO; P_LE | 16h | 320 |
| 11 | 1.1.1.6.2 | 1.1.5.2 - Avec le client | 4h | 2023-09-15 | 2023-09-20 |  | 0d |  | A_PE; A_PI; D_DA; K_MO; P_LE | 5h | 100 |
| 12 | 1.1.2 | **1.2 - Organisation du travail en équipe** | 10.75d | 2023-09-15 | 2023-09-29 |  | 134.08d |  |  | 8h | 160 |
| 13 | 1.1.2.1 | 1.2.1 - Mise en place du kanban | 2h | 2023-09-15 | 2023-09-28 |  | 134.83d |  | A_PE; D_DA | 2h | 40 |
| 14 | 1.1.2.2 | 1.2.2 - Mise en place du codefirst | 3h | 2023-09-28 | 2023-09-29 |  | 134.08d |  | D_DA | 3h | 60 |
| 15 | 1.1.2.3 | 1.2.3 - Mise en place du notion | 2h | 2023-09-15 | 2023-09-19 |  | 141.83d |  | D_DA; A_PE | 2h | 40 |
| 16 | 1.1.2.4 | 1.2.4 - Mise en place du discord | 0.5h | 2023-09-15 | 2023-09-15 |  | 144.58d |  | A_PE; A_PI | 1h | 20 |
| 17 | 1.1.3 | **1.3 - Planification du projet** | 12.5d | 2023-09-25 | 2023-10-12 |  | 78.09d |  |  | 24h | 480 |
| 18 | 1.1.3.1 | 1.3.1 - WBS | 6.5h | 2023-09-25 | 2023-09-29 | 5 | 78.09d | 0d | A_PE; K_MO | 10h | 200 |
| 19 | 1.1.3.2 | 1.3.2 - GANTT prévisionnel | 10h | 2023-09-29 | 2023-10-10 | 18 | 78.09d | 0d | A_PE; P_LE | 10h | 200 |
| 20 | 1.1.3.3 | 1.3.3 - PERT | 4h | 2023-10-10 | 2023-10-12 | 19 | 78.09d | 0d | A_PE; P_LE | 4h | 80 |
| 21 | 1.1.4 | **1.4 - Suivi de projet** | 125.58d | 2023-10-12 | 2024-04-04 |  | 0d |  |  | 59h | 1,180 |
| 22 | 1.1.4.1 | 1.4.1 - Indicateurs de suivi de projet | 4h | 2023-10-12 | 2023-10-16 | 20 | 78.09d | 0d | D_DA; A_PE | 4h | 80 |
| 23 | 1.1.4.2 | 1.4.2 - Préparation des vidéos | 3h | 2024-02-27 | 2024-02-29 | 24 | 25.82d |  | A_PE; A_PI; D_DA; K_MO; P_LE | 15h | 300 |
| 24 | 1.1.4.3 | 1.4.3 - Préparation des rapports globaux | 2h | 2024-02-26 | 2024-02-27 | 63 | 25.82d | 0d | A_PE; A_PI; D_DA; K_MO; P_LE | 10h | 200 |
| 25 | 1.1.4.4 | 1.4.4 - Préparation oral 1 | 5h | 2023-10-16 | 2023-10-26 | 22 | 78.09d | 0d | A_PE; A_PI; D_DA; K_MO; P_LE | 13h | 260 |
| 26 | 1.1.4.5 | 1.4.5 - Préparation oral 2 | 4.98h | 2023-10-27 | 2023-12-18 | 25 | 78.09d |  | A_PE; A_PI; K_MO; P_LE | 15h | 300 |
| 27 | 1.1.4.6 | 1.4.6 - GANTT réel | 2h | 2024-02-26 | 2024-04-04 | 63 | 0d |  | A_PI; A_PE | 2h | 40 |

| ID | WBS | Task | Type | Duration | Start | Finish | Predecessors | Total slack | Free slack | Resources | Work | Cost |
| --- | --- | --- | --- | --- | --- | --- | --- | --- | --- | --- | --- | --- |
| 28 | 1.2 | **2 - Développement** |  | 112.75d | 2023-09-20 | 2024-02-26 |  | 3d |  |  | 391.99h | 7,839.78 |
| 29 | 1.2.1 | **2.1 - Conception** |  | 62.1d | 2023-09-20 | 2023-12-15 |  | 3d |  |  | 77.23h | 1,544.62 |
| 30 | 1.2.1.1 | 2.1.1 - Communication (reseaux) |  | 7h | 2023-11-15 | 2023-12-15 | 31 | 39.38d | 0d | A_PE; P_LE | 7h | 140 |
| 31 | 1.2.1.2 | 2.1.2 - Architecture |  | 10h | 2023-11-08 | 2023-11-15 | 32 | 0d |  | A_PE; D_DA | 10h | 200 |
| 32 | 1.2.1.3 | 2.1.3 - Diagramme de classes |  | 10h | 2023-10-09 | 2023-11-08 | 34 | 0d |  | A_PE; A_PI; D_DA | 20.23h | 404.62 |
| 33 | 1.2.1.4 | 2.1.4 - Maquettes |  | 8h | 2023-09-25 | 2023-09-29 | 5 | 0d |  | A_PI | 8h | 160 |
| 34 | 1.2.1.5 | 2.1.5 - MCD & MLD |  | 12h | 2023-09-29 | 2023-10-09 | 33 | 0d |  | D_DA; P_LE; K_MO; A_PI; A_PE | 23h | 460 |
| 35 | 1.2.1.6 | 2.1.6 - Diagramme de cas d'utilisation |  | 8h | 2023-09-20 | 2023-09-29 | 11 | 75.94d | 33.1d | K_MO; A_PE | 8h | 160 |
| 36 | 1.2.1.7 | 2.1.8 - Logo |  | 1h | 2023-10-05 | 2023-10-05 |  | 130.08d |  | D_DA | 1h | 20 |
| 37 | 1.2.2 | **2.2 - Client Web et Mobile** |  | 58.14d | 2023-11-15 | 2024-02-05 |  | 37.63d |  |  | 146.86h | 2,937.27 |
| 38 | 1.2.2.1 | 2.2.1 - Interface utilisateur client (Vues) |  | 15h | 2023-11-20 | 2024-01-09 | 31 | 62.53d |  | A_PI | 15h | 300 |
| 39 | 1.2.2.2 | 2.2.2 - Gestion des données client |  | 40h | 2023-11-15 | 2023-12-13 | 31 | 37.63d | 0d | A_PE; D_DA; P_LE | 108.36h | 2,167.27 |
| 40 | 1.2.2.3 | 2.2.3 - Authentification Web et Mobile client |  | 3h | 2023-12-25 | 2024-02-05 | 30, 39, 43, 44, 45 | 42.84d |  | A_PI; K_MO; D_DA | 3h | 60 |
| 41 | 1.2.2.4 | 2.2.4 - Récupération des données de fréquence cardiaque |  | 15h | 2023-11-15 | 2023-12-28 | 31 | 70.74d |  | A_PE | 15h | 300 |
| 42 | 1.2.2.5 | 2.2.5 - Définitions des algoritmes d'analyse de la fréquence cardiaque | milestone | 0h | 2023-12-15 | 2023-12-22 | 30 | 73.98d |  | D_DA |  |  |
| 43 | 1.2.2.6 | 2.2.6 - Mise en place Bootstrap |  | 3h | 2023-11-15 | 2023-11-17 | 31, 35 | 68.83d | 26d | A_PI | 3h | 60 |
| 44 | 1.2.2.7 | 2.2.7 - Mise en place talwind |  | 1.5h | 2023-11-17 | 2023-11-20 | 31, 35 | 68.08d | 25.25d | A_PI | 1.5h | 30 |
| 45 | 1.2.2.8 | 2.2.8 - Mise en place lead PHPStorm |  | 1h | 2023-12-22 | 2023-12-25 | 31, 35 | 42.84d | 0d | D_DA | 1h | 20 |
| 46 | 1.2.3 | **2.3 - Web admin et monitorin** |  | 27.38d | 2023-11-22 | 2024-01-01 |  | 68.72d |  |  | 23.28h | 465.57 |
| 47 | 1.2.3.1 | 2.3.1 - Authentification admin et monitoring |  | 9.51h | 2023-12-25 | 2024-01-01 | 30 | 68.72d |  | A_PE; D_DA | 13.28h | 265.57 |
| 48 | 1.2.3.2 | 2.3.2 - Interface utilisateur admin (Vues) |  | 10h | 2023-11-22 | 2023-12-01 | 31 | 88.85d |  | A_PI | 10h | 200 |
| 49 | 1.2.4 | **2.4 - Base de données** |  | 43.35d | 2023-12-13 | 2024-02-13 |  | 37.63d |  |  | 23.55h | 471 |
| 50 | 1.2.4.1 | 2.4.1 - Création des tables |  | 2h | 2023-12-13 | 2023-12-14 | 39 | 37.63d | 0d | P_LE | 2h | 40 |
| 51 | 1.2.4.2 | 2.4.2 - Ajout des données |  | 1.55h | 2023-12-15 | 2023-12-22 | 50 | 72.98d | 35.35d | A_PE; D_DA | 1.55h | 31 |
| 52 | 1.2.4.3 | 2.4.3 - Mise en place d'un système de backup |  | 7.67h | 2023-12-14 | 2024-02-12 | 50 | 37.63d | 0d | A_PE; D_DA | 12h | 240 |
| 53 | 1.2.4.4 | 2.4.4 - Création des fonctions |  | 4h | 2023-12-15 | 2023-12-19 | 50 | 77.23d |  | A_PI | 4h | 80 |
| 54 | 1.2.4.5 | 2.4.5 - Création des index |  | 2h | 2024-02-12 | 2024-02-13 | 51, 52 | 37.63d |  | A_PE; D_DA | 4h | 80 |

| ID | WBS | Task | Duration | Start | Finish | Predecessors | Total slack | Free slack | Resources | Work | Cost |
| --- | --- | --- | --- | --- | --- | --- | --- | --- | --- | --- | --- |
| 55 | 1.2.5 | **2.5 - Serveur et communication de services** | 61.6d | 2023-11-15 | 2024-02-09 |  | 39.38d |  |  | 47.07h | 941.33 |
| 56 | 1.2.5.1 | 2.5.1 - Authentification serveur | 4h | 2023-12-15 | 2024-01-31 | 30 | 39.38d | 0d | A_PI; K_MO | 4h | 80 |
| 57 | 1.2.5.2 | 2.5.2 - Stockage cloud | 3.5h | 2024-01-31 | 2024-02-02 | 56, 58 | 39.38d | 0d | D_DA; A_PE; A_PI | 10.17h | 203.33 |
| 58 | 1.2.5.3 | 2.5.3 - Routage | 14.4h | 2023-11-15 | 2024-01-12 | 31 | 52.68d | 13.3d | A_PE; A_PI; D_DA | 17.9h | 358 |
| 59 | 1.2.5.4 | 2.5.4 - Gestion des données serveur | 10.17h | 2024-02-02 | 2024-02-09 | 57 | 39.38d |  | A_PI; A_PE; D_DA | 15h | 300 |
| 60 | 1.2.6 | **2.6 - Integration continue et livraison continue (CI/ CD)** | 72.66d | 2023-11-15 | 2024-02-26 |  | 0d |  |  | 74h | 1,480 |
| 61 | 1.2.6.1 | 2.6.1 - Tests | 40h | 2023-11-15 | 2024-01-23 | 31 | 0d |  | A_PE; A_PI; D_DA; K_MO; P_LE | 48h | 960 |
| 62 | 1.2.6.2 | 2.6.2 - Conteneurisation et déploiement | 8h | 2023-11-15 | 2024-01-23 | 31 | 52.58d |  | A_PE; D_DA | 8h | 160 |
| 63 | 1.2.6.3 | 2.6.3 - Documentations (swagger, schéma, …) | 6h | 2024-01-23 | 2024-02-26 | 61 | 0d |  | A_PE; A_PI; D_DA | 18h | 360 |
